# Estacion servicio EV_actualizado

Schedule from MS Project, 2025-01-02 to 2025-04-29, 11 hours a day, costs in ₡.
C

## Calendars

- Estándar: Mon-Fri 06:00-17:00; Sat-Sun off.

## Schedule

| ID | WBS | Task | Duration | Start | Finish | Predecessors | Total slack | Free slack | Cost |
| --- | --- | --- | --- | --- | --- | --- | --- | --- | --- |
| 1 | 1 | **CIMENTACION** | 21d | 2025-01-02 | 2025-01-30 |  | 0d |  | 7,650,000 |
| 2 | 1.1 | Realizar movimiento de tierras | 5d | 2025-01-02 | 2025-01-08 |  | 0d |  | 1,500,000 |
| 3 | 1.2 | Realizar excavacion de fundaciones | 8d | 2025-01-09 | 2025-01-20 | 2 | 0d |  | 3,450,000 |
| 4 | 1.3 | Elaborar armaduras fundaciones | 11d | 2025-01-15 | 2025-01-29 | 2FS-4d, 3FS-4d | 0d |  | 1,850,000 |
| 5 | 1.4 | Chorrear fundaciones | 5d | 2025-01-24 | 2025-01-30 | 4FS-4d | 7d | 0d | 850,000 |
| 6 | 2 | **OBRA GRIS** | 46d | 2025-01-17 | 2025-03-21 |  | 1d |  | 52,275,000 |
| 7 | 2.1 | Trabajar mamposteria | 12d | 2025-02-04 | 2025-02-19 | 5FS+2d | 16d |  | 1,250,000 |
| 8 | 2.2 | Realizar armaduras de columnas | 8d | 2025-01-20 | 2025-01-30 | 4SS+3d | 0d |  | 1,300,000 |
| 9 | 2.3 | Colocar formaleta a columnas | 6d | 2025-01-27 | 2025-02-04 | 8FS-3d | 0d |  | 770,000 |
| 10 | 2.4 | Chorrear columnas | 4d | 2025-01-30 | 2025-02-04 | 9FS-3d | 0d |  | 960,000 |
| 11 | 2.5 | Fabricar estructura metalica | 10d | 2025-01-17 | 2025-01-30 | 4SS+2d | 3d | 0d | 23,000,000 |
| 12 | 2.6 | Maontar estructura mecanica | 11d | 2025-02-05 | 2025-02-19 | 10, 11 | 0d |  | 2,500,000 |
| 13 | 2.7 | Hacer armadura de vigas de concreto | 6d | 2025-01-22 | 2025-01-29 | 4SS+5d | 49d | 0d | 345,000 |
| 14 | 2.8 | Colocar formaleta de vigas de concreto | 4d | 2025-01-29 | 2025-02-03 | 13FS-1d | 49d | 0d | 250,000 |
| 15 | 2.9 | Chorrear vigas de concreto | 2d | 2025-02-04 | 2025-02-05 | 14 | 49d | 0d | 265,000 |
| 16 | 2.10 | Colocar losas de techo | 2d | 2025-02-06 | 2025-02-07 | 15 | 49d |  | 450,000 |
| 17 | 2.11 | Fabrica estructura de techos | 8d | 2025-02-04 | 2025-02-13 | 11FS+2d | 4d |  | 16,000,000 |
| 18 | 2.12 | Montar estructura de techo | 8d | 2025-02-20 | 2025-03-03 | 12, 17 | 0d |  | 2,000,000 |
| 19 | 2.13 | Colocar cubierta | 4d | 2025-03-04 | 2025-03-07 | 18 | 0d |  | 1,950,000 |
| 20 | 2.14 | Chorrear contrapiso | 4d | 2025-03-10 | 2025-03-13 | 19 | 0d |  | 625,000 |
| 21 | 2.15 | Pomer repellos | 6d | 2025-03-14 | 2025-03-21 | 7, 20 | 0d |  | 610,000 |
| 22 | 3 | **ACABADOS** | 25d | 2025-03-24 | 2025-04-25 |  | 0d |  | 15,150,000 |
| 23 | 3.1 | Colocar paredes livianas | 8d | 2025-03-24 | 2025-04-02 | 21 | 0d |  | 6,500,000 |
| 24 | 3.2 | Colocar cielos | 6d | 2025-04-03 | 2025-04-10 | 23 | 0d |  | 2,700,000 |
| 25 | 3.3 | Poner enchapes | 3d | 2025-04-11 | 2025-04-15 | 24 | 0d |  | 800,000 |
| 26 | 3.4 | Colocar puertas | 2d | 2025-04-16 | 2025-04-17 | 25 | 0d |  | 675,000 |
| 27 | 3.5 | Colocar ventanas | 4d | 2025-04-16 | 2025-04-21 | 25 | 0d |  | 1,275,000 |
| 28 | 3.6 | Colocar cortinas de acero | 3d | 2025-04-18 | 2025-04-22 | 26 | 0d |  | 900,000 |
| 29 | 3.7 | Pintar | 6d | 2025-04-18 | 2025-04-25 | 16, 27SS+2d | 0d |  | 2,300,000 |

| ID | WBS | Task | Type | Duration | Start | Finish | Predecessors | Total slack | Free slack | Cost |
| --- | --- | --- | --- | --- | --- | --- | --- | --- | --- | --- |
| 30 | 4 | **OBRAS E INSTALACIONES** |  | 59d | 2025-01-21 | 2025-04-11 |  | 7d |  | 65,600,000 |
| 31 | 4.1 | Realizar obras exteriores |  | 55d | 2025-01-21 | 2025-04-07 | 3 | 11d |  | 55,000,000 |
| 32 | 4.2 | Hacer instalaciones mecanicas |  | 50d | 2025-02-03 | 2025-04-11 | 5FS+1d | 7d | 0d | 4,850,000 |
| 33 | 4.3 | Hacer instalaciones electricas |  | 50d | 2025-02-03 | 2025-04-11 | 32SS | 7d |  | 5,750,000 |
| 34 | 5 | Limpiar |  | 5d | 2025-04-23 | 2025-04-29 | 26, 27, 28, 29FS-3d, 31, 32, 33 | 0d |  | 500,000 |
| 35 | 6 | Finalizar proyecto | milestone | 0d | 2025-04-29 | 2025-04-29 | 34 | 0d |  |  |
